Schedule from GanttProject, 2018-08-27 to 2019-03-06.

## Calendars

- Project calendar: Mon-Fri working; Sat-Sun off.

## Resources

| Resource |
| --- |
| JC Park |
| Lintondria Dennis |
| James Smith |
| Garrett Dupree |
| Sean Ponce |
| Jakob Parnell |

## Schedule

| ID | WBS | Task | Duration | Start | Finish | Complete |
| --- | --- | --- | --- | --- | --- | --- |
| 1 | 1 | **1.0 Research** | 5d | 2018-08-27 | 2018-08-31 | 83% |
| 2 | 1.1 | **1.1 Hardware Research** | 5d | 2018-08-27 | 2018-08-31 | 100% |
| 3 | 1.1.1 | **1.1.1 Altium** | 5d | 2018-08-27 | 2018-08-31 | 100% |
| 4 | 1.1.1.1 | 1.1.1.1 Library Research | 5d | 2018-08-27 | 2018-08-31 | 100% |
| 5 | 1.1.1.2 | 1.1.1.2 Schematic Research | 5d | 2018-08-27 | 2018-08-31 | 100% |
| 6 | 1.1.1.3 | 1.1.1.3 Layout Research | 5d | 2018-08-27 | 2018-08-31 | 100% |
| 7 | 1.1.2 | **1.1.2 Beaglebone SIP** | 5d | 2018-08-27 | 2018-08-31 | 100% |
| 8 | 1.1.2.1 | 1.1.2.1 Expansion Header Pinout | 1d | 2018-08-27 | 2018-08-27 | 100% |
| 9 | 1.1.2.2 | 1.1.2.2 Mounting on/to Board | 5d | 2018-08-27 | 2018-08-31 | 100% |
| 10 | 1.1.2.3 | 1.1.2.3 Beaglebone Procurement | 3d | 2018-08-27 | 2018-08-29 | 100% |
| 11 | 1.1.3 | **1.1.3 Bus Assessment** | 1d | 2018-08-27 | 2018-08-27 | 100% |
| 12 | 1.1.3.1 | 1.1.3.1 Dimensions | 1d | 2018-08-27 | 2018-08-27 | 100% |
| 13 | 1.1.3.2 | 1.1.3.2 Pinouts | 1d | 2018-08-27 | 2018-08-27 | 100% |
| 14 | 1.1.4 | **1.1.4 Layer Physical Deminsions** | 5d | 2018-08-27 | 2018-08-31 | 100% |
| 15 | 1.1.4.1 | 1.1.4.1 Determine Maximum PCB Deminsions | 1d | 2018-08-27 | 2018-08-27 | 100% |
| 16 | 1.1.4.2 | 1.1.4.2 Determine Number of Layers | 1d | 2018-08-27 | 2018-08-27 | 100% |
| 17 | 1.1.4.3 | 1.1.4.3 Investigate Possible Restrictions | 3d | 2018-08-27 | 2018-08-29 | 100% |
| 18 | 1.1.4.4 | 1.1.4.4 Maximum Component Dimensions | 5d | 2018-08-27 | 2018-08-31 | 100% |
| 19 | 1.1.4.5 | 1.1.4.5 External Expansions Header(s) | 1d | 2018-08-27 | 2018-08-27 | 100% |
| 20 | 1.1.5 | 1.1.5 Power Budget | 5d | 2018-08-27 | 2018-08-31 | 100% |
| 21 | 1.2 | **1.2 Software Research** | 5d | 2018-08-27 | 2018-08-31 | 100% |
| 22 | 1.2.1 | **1.2.1 Linux OS** | 5d | 2018-08-27 | 2018-08-31 | 100% |
| 23 | 1.2.1.1 | 1.2.1.1 Linux Architecture Research | 2d | 2018-08-27 | 2018-08-28 | 100% |
| 24 | 1.2.1.2 | 1.2.1.2 Learn Linux Installation Process | 5d | 2018-08-27 | 2018-08-31 | 100% |

| ID | WBS | Task | Duration | Start | Finish | Predecessors | Complete |
| --- | --- | --- | --- | --- | --- | --- | --- |
| 25 | 1.2.2 | **1.2.2 802.3 Communication** | 5d | 2018-08-27 | 2018-08-31 |  | 100% |
| 26 | 1.2.2.1 | 1.2.2.1 Identify 802.3 pins on PocketBeagle | 1d | 2018-08-27 | 2018-08-27 |  | 100% |
| 27 | 1.2.2.2 | 1.2.2.2 Protocol Research | 3d | 2018-08-27 | 2018-08-29 |  | 100% |
| 28 | 1.2.2.3 | 1.2.2.3 Data Aquisition and Transmission Research | 5d | 2018-08-27 | 2018-08-31 |  | 100% |
| 29 | 1.2.3 | 1.2.3 Python Language Research | 1d | 2018-08-27 | 2018-08-27 |  | 100% |
| 30 | 1.3 | **1.3 Integration Reseach** | 2d | 2018-08-27 | 2018-08-28 |  |  |
| 31 | 1.3.1 | 1.3.1 Communication Layer Functionality Reseach | 2d | 2018-08-27 | 2018-08-28 |  |  |
| 32 | 1.3.2 | 1.3.2 Sensor Layer Functionality Reseach | 2d | 2018-08-27 | 2018-08-28 |  |  |
| 33 | 1.3.3 | 1.3.3 Communication Layer Procurement | 1d | 2018-08-27 | 2018-08-27 |  |  |
| 34 | 1.3.4 | 1.3.4 Sensor Layer Procurement | 1d | 2018-08-27 | 2018-08-27 |  |  |
| 35 | 2 | **2.0 Design** | 116d | 2018-08-29 | 2019-02-06 |  | 18% |
| 36 | 2.1 | **2.1 Hardware Design** | 113d | 2018-09-03 | 2019-02-06 |  | 18% |
| 37 | 2.1.1 | **2.1.1 Alpha Design** | 19d | 2018-09-03 | 2018-09-27 |  | 100% |
| 38 | 2.1.1.1 | 2.1.1.1 Schematic | 15d | 2018-09-03 | 2018-09-21 | 4, 5, 8, 9, 12, 13, 18, 19, 20 | 100% |
| 39 | 2.1.1.2 | 2.1.1.2 Custom Schematic Library | 4d | 2018-09-24 | 2018-09-27 | 38 | 100% |
| 40 | 2.1.2 | **2.1.2 Alpha Board Layout** | 10d | 2018-09-28 | 2018-10-11 |  |  |
| 41 | 2.1.2.1 | 2.1.2.1 Power Management Layout | 10d | 2018-09-28 | 2018-10-11 | 6, 15, 16, 17, 39 |  |
| 42 | 2.1.2.2 | 2.1.2.2 BreakOff Board Layout | 5d | 2018-09-28 | 2018-10-04 | 6, 15, 16, 17, 39 |  |
| 43 | 2.1.3 | **2.1.3 Alpha Procurement** | 28d | 2018-09-24 | 2018-10-31 |  | 16% |
| 44 | 2.1.3.1 | 2.1.3.1 Componets | 3d | 2018-09-24 | 2018-09-26 | 38 | 95% |
| 45 | 2.1.3.2 | 2.1.3.2 Board | 14d | 2018-10-12 | 2018-10-31 | 41, 42 |  |
| 46 | 2.1.4 | **2.1.4 Beta Design** | 9d | 2018-11-13 | 2018-11-23 |  |  |
| 47 | 2.1.4.1 | 2.1.4.1 Schematic | 7d | 2018-11-13 | 2018-11-21 | 151 |  |
| 48 | 2.1.4.2 | 2.1.4.2 Custom Schematic Layout | 2d | 2018-11-22 | 2018-11-23 | 47 |  |

| ID | WBS | Task | Duration | Start | Finish | Predecessors | Complete |
| --- | --- | --- | --- | --- | --- | --- | --- |
| 49 | 2.1.5 | **2.1.5 Beta Board Layout** | 7d | 2018-11-26 | 2018-12-04 |  |  |
| 50 | 2.1.5.1 | 2.1.5.1 Power Management Layout | 7d | 2018-11-26 | 2018-12-04 | 48 |  |
| 51 | 2.1.5.2 | 2.1.5.2 BreakOff Board Layout | 7d | 2018-11-26 | 2018-12-04 | 48 |  |
| 52 | 2.1.6 | **2.1.6 Beta Procurement** | 24d | 2018-11-22 | 2018-12-25 |  |  |
| 53 | 2.1.6.1 | 2.1.6.1 Components | 3d | 2018-11-22 | 2018-11-26 | 47 |  |
| 54 | 2.1.6.2 | 2.1.6.2 Board | 15d | 2018-12-05 | 2018-12-25 | 50, 51 |  |
| 55 | 2.1.7 | **2.1.7 Final Design** | 6d | 2019-01-07 | 2019-01-14 |  |  |
| 56 | 2.1.7.1 | 2.1.7.1 Schematic | 5d | 2019-01-07 | 2019-01-11 | 152 |  |
| 57 | 2.1.7.2 | 2.1.7.2 Custom Schematic Library | 1d | 2019-01-14 | 2019-01-14 | 56 |  |
| 58 | 2.1.8 | **2.1.8 Final Board Layout** | 3d | 2019-01-15 | 2019-01-17 |  |  |
| 59 | 2.1.8.1 | 2.1.8.1 Power Management Layout | 3d | 2019-01-15 | 2019-01-17 | 57 |  |
| 60 | 2.1.8.2 | 2.1.8.2 BreakOff Board Layout | 3d | 2019-01-15 | 2019-01-17 | 57 |  |
| 61 | 2.1.9 | **2.1.9 Final Procurement** | 18d | 2019-01-14 | 2019-02-06 |  |  |
| 62 | 2.1.9.1 | 2.1.9.1 Components | 3d | 2019-01-14 | 2019-01-16 | 56 |  |
| 63 | 2.1.9.2 | 2.1.9.2 Board | 14d | 2019-01-18 | 2019-02-06 | 59, 60 |  |
| 64 | 2.2 | **2.2 Software Design** | 7d | 2018-09-03 | 2018-09-11 |  | 36% |
| 65 | 2.2.1 | **2.2.1 Flowchart Design** | 7d | 2018-09-03 | 2018-09-11 |  | 36% |
| 66 | 2.2.1.1 | 2.2.1.1 Intelligence + OS Interaction | 4d | 2018-09-03 | 2018-09-06 | 23, 24, 29 | 100% |
| 67 | 2.2.1.2 | 2.2.1.2 Communication | 7d | 2018-09-03 | 2018-09-11 | 26, 27, 28, 29 |  |
| 68 | 2.3 | **2.3 Integration Design** | 5d | 2018-08-29 | 2018-09-04 |  |  |
| 69 | 2.3.1 | 2.3.1 Communication Layer Flowchart Design | 5d | 2018-08-29 | 2018-09-04 | 31 |  |
| 70 | 2.3.2 | 2.3.2 Sensor Layer Flowchart Design | 1d | 2018-08-29 | 2018-08-29 | 32 |  |
| 71 | 3 | **3.0 Development** | 124d | 2018-08-30 | 2019-02-19 |  |  |
| 72 | 3.1 | **3.1 Hardware Development** | 79d | 2018-11-01 | 2019-02-19 |  |  |
| 73 | 3.1.1 | **3.1.1 Alpha Board Population** | 7d | 2018-11-06 | 2018-11-14 |  |  |
| 74 | 3.1.1.1 | 3.1.1.1 Power Population | 3d | 2018-11-06 | 2018-11-08 | 44, 79 |  |
| 75 | 3.1.1.2 | 3.1.1.2 Microcomputer Population | 1d | 2018-11-12 | 2018-11-12 | 10, 80 |  |
| 76 | 3.1.1.3 | 3.1.1.3 Bus Out Population | 3d | 2018-11-12 | 2018-11-14 | 44, 80 |  |

| ID | WBS | Task | Duration | Start | Finish | Predecessors |
| --- | --- | --- | --- | --- | --- | --- |
| 77 | 3.1.2 | **3.1.2 Alpha Board Test** | 7d | 2018-11-01 | 2018-11-09 |  |
| 78 | 3.1.2.1 | 3.1.2.1 Bare Board Voltage Test | 1d | 2018-11-01 | 2018-11-01 | 45 |
| 79 | 3.1.2.2 | 3.1.2.2 Trace Test | 2d | 2018-11-02 | 2018-11-05 | 78 |
| 80 | 3.1.2.3 | 3.1.2.3 Power Test | 1d | 2018-11-09 | 2018-11-09 | 74 |
| 81 | 3.1.3 | **3.1.3 Beta Board Population** | 7d | 2018-12-31 | 2019-01-08 |  |
| 82 | 3.1.3.1 | 3.1.3.1 Power Population | 3d | 2018-12-31 | 2019-01-02 | 53, 87 |
| 83 | 3.1.3.2 | 3.1.3.2 Microcomputer Population | 1d | 2019-01-04 | 2019-01-04 | 10, 88 |
| 84 | 3.1.3.3 | 3.1.3.3 Bus Out Population | 3d | 2019-01-04 | 2019-01-08 | 53, 88 |
| 85 | 3.1.4 | **3.1.4 Beta Board Test** | 7d | 2018-12-26 | 2019-01-03 |  |
| 86 | 3.1.4.1 | 3.1.4.1 Bare Board Voltage Test | 1d | 2018-12-26 | 2018-12-26 | 54 |
| 87 | 3.1.4.2 | 3.1.4.2 Trace Test | 2d | 2018-12-27 | 2018-12-28 | 86 |
| 88 | 3.1.4.3 | 3.1.4.3 Power Test | 1d | 2019-01-03 | 2019-01-03 | 82 |
| 89 | 3.1.5 | **3.1.5 Final Board Population** | 6d | 2019-02-12 | 2019-02-19 |  |
| 90 | 3.1.5.1 | 3.1.5.1 Power Population | 3d | 2019-02-12 | 2019-02-14 | 62, 95 |
| 91 | 3.1.5.2 | 3.1.5.2 Microcomputer Population | 1d | 2019-02-18 | 2019-02-18 | 10, 96 |
| 92 | 3.1.5.3 | 3.1.5.3 Bus Out Population | 2d | 2019-02-18 | 2019-02-19 | 62, 96 |
| 93 | 3.1.6 | **3.1.6 Final Board Test** | 7d | 2019-02-07 | 2019-02-15 |  |
| 94 | 3.1.6.1 | 3.1.6.1 Bare Board Voltage Test | 1d | 2019-02-07 | 2019-02-07 | 63 |
| 95 | 3.1.6.2 | 3.1.6.2 Trace Test | 2d | 2019-02-08 | 2019-02-11 | 94 |
| 96 | 3.1.6.3 | 3.1.6.3 Power Test | 1d | 2019-02-15 | 2019-02-15 | 90 |
| 97 | 3.2 | **3.2 Software Development** | 87d | 2018-09-12 | 2019-01-10 |  |
| 98 | 3.2.1 | **3.2.1 Alpha Software Creation** | 23d | 2018-09-12 | 2018-10-12 |  |
| 99 | 3.2.1.1 | 3.2.1.1 Verify Pin Functionality | 1d | 2018-10-12 | 2018-10-12 | 40 |
| 100 | 3.2.1.2 | 3.2.1.2 TCP Server Configuration | 1d | 2018-09-12 | 2018-09-12 | 67 |

| ID | WBS | Task | Duration | Start | Finish | Predecessors |
| --- | --- | --- | --- | --- | --- | --- |
| 101 | 3.2.2 | **3.2.2 Alpha Software Test** | 25d | 2018-09-13 | 2018-10-17 |  |
| 102 | 3.2.2.1 | 3.2.2.1 Verify Pin Functionality | 3d | 2018-10-15 | 2018-10-17 | 99 |
| 103 | 3.2.2.2 | 3.2.2.2 Setting Up TCP Server | 1d | 2018-09-13 | 2018-09-13 | 100 |
| 104 | 3.2.3 | **3.2.3 Beta Software Creation** | 1d | 2018-11-13 | 2018-11-13 |  |
| 105 | 3.2.3.1 | 3.2.3.1 Verify Pin Functionality | 1d | 2018-11-13 | 2018-11-13 | 151 |
| 106 | 3.2.3.2 | 3.2.3.2 TCP Server Configuration | 1d | 2018-11-13 | 2018-11-13 | 151 |
| 107 | 3.2.4 | **3.2.4 Beta Software Test** | 3d | 2018-11-14 | 2018-11-16 |  |
| 108 | 3.2.4.1 | 3.2.4.1 Verify Pin Functionality | 3d | 2018-11-14 | 2018-11-16 | 105 |
| 109 | 3.2.4.2 | 3.2.4.2 Setting Up TCP Server | 1d | 2018-11-14 | 2018-11-14 | 106 |
| 110 | 3.2.5 | **3.2.5 Final Software Creation** | 1d | 2019-01-07 | 2019-01-07 |  |
| 111 | 3.2.5.1 | 3.2.5.1 Verify Pin Functionality | 1d | 2019-01-07 | 2019-01-07 | 152 |
| 112 | 3.2.5.2 | 3.2.5.2 TCP Server Configuration | 1d | 2019-01-07 | 2019-01-07 | 152 |
| 113 | 3.2.6 | **3.2.6 Final Software Test** | 3d | 2019-01-08 | 2019-01-10 |  |
| 114 | 3.2.6.1 | 3.2.6.1 Verify Pin Functionality | 3d | 2019-01-08 | 2019-01-10 | 111 |
| 115 | 3.2.6.2 | 3.2.6.2 Setting Up TCP Server | 1d | 2019-01-08 | 2019-01-08 | 112 |
| 116 | 3.3 | **3.3 Integration Development** | 57d | 2018-08-30 | 2018-11-16 |  |
| 117 | 3.3.1 | **3.3.1 Alpha Layer Interaction Creation** | 15d | 2018-08-30 | 2018-09-19 |  |
| 118 | 3.3.1.1 | 3.3.1.1 Data Aquisition | 5d | 2018-08-30 | 2018-09-05 | 70 |
| 119 | 3.3.1.2 | 3.3.1.2 Communication Connection | 5d | 2018-09-13 | 2018-09-19 | 69, 100, 156 |
| 120 | 3.3.1.3 | 3.3.1.3 Host PC Communication | 1d | 2018-09-13 | 2018-09-13 | 69, 100, 156 |
| 121 | 3.3.2 | **3.3.2 Alpha Layer Interaction Test** | 11d | 2018-09-06 | 2018-09-20 |  |
| 122 | 3.3.2.1 | 3.3.2.1 Data Aquistion Test | 1d | 2018-09-06 | 2018-09-06 | 118 |
| 123 | 3.3.2.2 | 3.3.2.2 Communication Connection Test | 1d | 2018-09-20 | 2018-09-20 | 119 |
| 124 | 3.3.2.3 | 3.3.2.3 Host PC Communication Test | 1d | 2018-09-14 | 2018-09-14 | 120 |

| ID | WBS | Task | Duration | Start | Finish | Predecessors |
| --- | --- | --- | --- | --- | --- | --- |
| 125 | 3.3.3 | **3.3.3 Beta Layer Interaction Creation** | 56d | 2018-08-30 | 2018-11-15 |  |
| 126 | 3.3.3.1 | 3.3.3.1 Data Aquisition | 3d | 2018-08-30 | 2018-09-03 |  |
| 127 | 3.3.3.2 | 3.3.3.2 Communication Connection | 3d | 2018-11-13 | 2018-11-15 | 151 |
| 128 | 3.3.3.3 | 3.3.3.3 Host PC Communication | 1d | 2018-11-13 | 2018-11-13 | 151 |
| 129 | 3.3.4 | **3.3.4 Beta Layer Interaction Test** | 54d | 2018-09-04 | 2018-11-16 |  |
| 130 | 3.3.4.1 | 3.3.4.1 Data Aquistion Test | 1d | 2018-09-04 | 2018-09-04 | 126 |
| 131 | 3.3.4.2 | 3.3.4.2 Communication Connection Test | 1d | 2018-11-16 | 2018-11-16 | 127 |
| 132 | 3.3.4.3 | 3.3.4.3 Host PC Communication Test | 1d | 2018-11-14 | 2018-11-14 | 128 |
| 133 | 3.3.5 | **3.3.5 Final Layer Interaction Creation** | 6d | 2018-08-30 | 2018-09-06 |  |
| 134 | 3.3.5.1 | 3.3.5.1 Data Aquisition | 2d | 2018-08-30 | 2018-08-31 |  |
| 135 | 3.3.5.2 | 3.3.5.2 Communication Connection | 2d | 2018-09-05 | 2018-09-06 |  |
| 136 | 3.3.5.3 | 3.3.5.3 Host PC Communication | 1d | 2018-09-05 | 2018-09-05 |  |
| 137 | 3.3.6 | **3.3.6 Final Layer Interaction Test** | 5d | 2018-09-03 | 2018-09-07 |  |
| 138 | 3.3.6.1 | 3.3.6.1 Data Aquistion Test | 1d | 2018-09-03 | 2018-09-03 | 134 |
| 139 | 3.3.6.2 | 3.3.6.2 Communication Connection Test | 1d | 2018-09-07 | 2018-09-07 | 135 |
| 140 | 3.3.6.3 | 3.3.6.3 Host PC Communication Test | 1d | 2018-09-06 | 2018-09-06 | 136 |
| 141 | 4 | **4.0 Test** | 121d | 2018-09-03 | 2019-02-18 |  |
| 142 | 4.1 | 4.1 Matrix | 1d | 2018-09-03 | 2018-09-03 | 12, 15, 18 |
| 143 | 4.2 | **4.2 Writing Plan** | 2d | 2018-09-04 | 2018-09-05 |  |
| 144 | 4.2.1 | **4.2.1 Hardware Test Implementation** | 2d | 2018-09-04 | 2018-09-05 |  |
| 145 | 4.2.1.1 | 4.2.1.1 Complete Power Test | 1d | 2018-09-04 | 2018-09-04 | 142 |
| 146 | 4.2.1.2 | 4.2.1.2 Connection Test | 2d | 2018-09-04 | 2018-09-05 | 142 |
| 147 | 4.2.2 | **4.2.2 Software Test Implementation** | 1d | 2018-09-04 | 2018-09-04 |  |
| 148 | 4.2.2.1 | 4.2.2.1 Functionality Test | 1d | 2018-09-04 | 2018-09-04 | 142 |
| 149 | 4.2.2.2 | 4.2.2.2 Communications Test | 1d | 2018-09-04 | 2018-09-04 | 142 |

| ID | WBS | Task | Duration | Start | Finish | Predecessors |
| --- | --- | --- | --- | --- | --- | --- |
| 150 | 4.3 | **4.3 Plan Implementation Check Points** | 71d | 2018-11-12 | 2019-02-18 |  |
| 151 | 4.3.1 | 4.3.1 Alpha Test Plan Check Point | 1d | 2018-11-12 | 2018-11-12 | 80, 101, 143, 157, 162 |
| 152 | 4.3.2 | 4.3.2 Beta Test Plan Check Point | 1d | 2019-01-04 | 2019-01-04 | 85, 107, 158, 163 |
| 153 | 4.3.3 | 4.3.3 Final Test Plan Check Point | 1d | 2019-02-18 | 2019-02-18 | 93, 113, 159, 164 |
| 154 | 4.4 | **4.4 Integration Test Check Points** | 53d | 2018-09-06 | 2018-11-19 |  |
| 155 | 4.4.1 | **4.4.1 Communication Layer Test** | 53d | 2018-09-06 | 2018-11-19 | 118, 126, 134 |
| 156 | 4.4.1.1 | 4.4.1.1 Communications Layer Alpha Initial Check | 1d | 2018-09-06 | 2018-09-06 | 33 |
| 157 | 4.4.1.2 | 4.4.1.2 Communications Layer Alpha Final Check | 1d | 2018-09-21 | 2018-09-21 | 123, 124 |
| 158 | 4.4.1.3 | 4.4.1.3 Communications Layer Beta Final Check | 1d | 2018-11-19 | 2018-11-19 | 131, 132 |
| 159 | 4.4.1.4 | 4.4.1.4 Communications Layer Final Final Check | 1d | 2018-09-10 | 2018-09-10 | 139, 140 |
| 160 | 4.4.2 | **4.4.2 Sensor Layer Test** | 2d | 2018-09-06 | 2018-09-07 | 118, 126, 134 |
| 161 | 4.4.2.1 | 4.4.2.1 Sensor Layer Alpha Initial Check | 1d | 2018-09-06 | 2018-09-06 | 34 |
| 162 | 4.4.2.2 | 4.4.2.2 Sensor Layer Alpha Final Check | 1d | 2018-09-07 | 2018-09-07 | 122 |
| 163 | 4.4.2.3 | 4.4.2.3 Sensor Layer Beta Final Check | 1d | 2018-09-06 | 2018-09-06 | 1, 130 |
| 164 | 4.4.2.4 | 4.4.2.4 Sensor Layer Final Final Check | 1d | 2018-09-06 | 2018-09-06 | 1, 138 |
| 165 | 5 | **5.0 Documentation** | 38d | 2019-01-08 | 2019-02-28 |  |
| 166 | 5.1 | **5.1 Hardware Documentation** | 33d | 2019-01-15 | 2019-02-28 |  |
| 167 | 5.1.1 | **5.1.1 User Guides** | 33d | 2019-01-15 | 2019-02-28 |  |
| 168 | 5.1.1.1 | 5.1.1.1 Installation | 7d | 2019-02-20 | 2019-02-28 | 89 |
| 169 | 5.1.1.2 | 5.1.1.2 Operation | 10d | 2019-01-15 | 2019-01-28 | 55 |
| 170 | 5.1.2 | 5.1.2 Design Report | 5d | 2019-01-15 | 2019-01-21 | 55 |
| 171 | 5.2 | **5.2 Software Documentation** | 12d | 2019-01-08 | 2019-01-23 |  |
| 172 | 5.2.1 | **5.2.1 User Guides** | 12d | 2019-01-08 | 2019-01-23 |  |
| 173 | 5.2.1.1 | 5.2.1.1 Program Setup | 7d | 2019-01-08 | 2019-01-16 | 110 |
| 174 | 5.2.1.2 | 5.2.1.2 Program Usage | 9d | 2019-01-11 | 2019-01-23 | 113 |
| 175 | 5.2.2 | 5.2.2 Development Report | 5d | 2019-01-08 | 2019-01-14 | 110 |

| ID | WBS | Task | Duration | Start | Finish | Predecessors |
| --- | --- | --- | --- | --- | --- | --- |
| 176 | 6 | **6.0 Close Out** | 128d | 2018-09-10 | 2019-03-06 |  |
| 177 | 6.1 | **6.1 General Close Out** | 12d | 2019-02-19 | 2019-03-06 |  |
| 178 | 6.1.1 | 6.1.1 Deliverables Check | 3d | 2019-03-01 | 2019-03-05 | 167, 170, 172, 175, 182, 183, 184, 186, 187, 188, 189 |
| 179 | 6.1.2 | 6.1.2 Final Demo | 5d | 2019-02-19 | 2019-02-25 | 153 |
| 180 | 6.1.3 | 6.1.3 Close Accounts | 1d | 2019-03-06 | 2019-03-06 | 178, 179 |
| 181 | 6.2 | **6.2 Hardware Close Out** | 5d | 2019-01-14 | 2019-01-18 |  |
| 182 | 6.2.1 | 6.2.1 Complete BOM | 1d | 2019-01-14 | 2019-01-14 | 56 |
| 183 | 6.2.2 | 6.2.2 Footprint Files | 1d | 2019-01-18 | 2019-01-18 | 59, 60 |
| 184 | 6.2.3 | 6.2.3 Gerber & Drill Files | 1d | 2019-01-18 | 2019-01-18 | 59, 60 |
| 185 | 6.3 | **6.3 Software Close Out** | 90d | 2018-09-10 | 2019-01-11 |  |
| 186 | 6.3.1 | 6.3.1 Hermes Source Code | 1d | 2019-01-11 | 2019-01-11 | 113 |
| 187 | 6.3.2 | 6.3.2 TSat Source Code | 1d | 2019-01-11 | 2019-01-11 | 113 |
| 188 | 6.3.3 | 6.3.3 Kernel File | 1d | 2019-01-11 | 2019-01-11 | 113 |
| 189 | 6.3.4 | 6.3.4 Layer Interaction Program Code | 1d | 2018-09-10 | 2018-09-10 | 137 |
