# Filler project

Schedule from GanttProject, 2018-06-01 to 2021-07-21.
Suisselle
Holidays every year on 01-01, 01-02, 08-01, 12-25, 12-26

## Calendars

- Project calendar: Mon-Fri working; Sat-Sun off. Exceptions (off unless hours are given): 2018-07-19 (Vacances sur 19.07.18 00:00), 2018-07-20, 2018-07-23 to 2018-07-27, 2018-07-30 to 2018-08-03, 2018-08-06 to 2018-08-10.

## Schedule

| ID | WBS | Task | Type | Duration | Start | Finish | Predecessors |
| --- | --- | --- | --- | --- | --- | --- | --- |
| 1 | 1 | **Planning and Input Design stage** |  | 82d | 2018-07-09 | 2018-11-22 |  |
| 2 | 1.1 | Kick-off meeting | milestone | 0d | 2018-08-23 | 2018-08-23 | 3 |
| 3 | 1.2 | Project charter |  | 16d | 2018-07-09 | 2018-08-22 |  |
| 4 | 1.3 | Product Requirement specifications |  | 8d | 2018-08-13 | 2018-08-22 |  |
| 5 | 1.4 | Initial Risk Analysis |  | 50d | 2018-08-23 | 2018-10-31 | 2 |
| 6 | 1.5 | Risk management plan |  | 50d | 2018-08-23 | 2018-10-31 | 2 |
| 7 | 1.6 | **Design and development plan / CH-FO-131** |  | 50d | 2018-08-23 | 2018-10-31 |  |
| 8 | 1.6.1 | FTO/IP assessment |  | 50d | 2018-08-23 | 2018-10-31 | 2 |
| 9 | 1.6.2 | Go to market plan |  | 50d | 2018-08-23 | 2018-10-31 | 2 |
| 10 | 1.6.3 | Verification and Validation plan |  | 50d | 2018-08-23 | 2018-10-31 | 2 |
| 11 | 1.6.4 | Development plan |  | 50d | 2018-08-23 | 2018-10-31 | 2 |
| 12 | 1.6.5 | Design transfer plan |  | 50d | 2018-08-23 | 2018-10-31 | 2 |
| 13 | 1.6.6 | Regulatory plan |  | 50d | 2018-08-23 | 2018-10-31 | 2 |
| 14 | 1.6.7 | Sourcing plan |  | 50d | 2018-08-23 | 2018-10-31 | 2 |
| 15 | 1.6.8 | Quality control plan |  | 50d | 2018-08-23 | 2018-10-31 | 2 |
| 16 | 1.7 | RACI matrix |  | 16d | 2018-07-09 | 2018-08-22 |  |
| 17 | 1.8 | COGs estimation |  | 16d | 2018-11-01 | 2018-11-22 | 9, 14 |
| 18 | 1.9 | Technical Design Input - CH-FO-132 |  | 30d | 2018-08-23 | 2018-10-03 | 2, 3, 4 |
| 19 | 1.10 | Design review 1 | milestone | 0d | 2018-11-01 | 2018-11-01 | 3, 4, 5, 6, 7, 18 |
| 20 | 2 | **Design and Development step** |  | 491d | 2018-10-04 | 2020-09-02 |  |
| 21 | 2.1 | **Process Development workpackage** |  | 491d | 2018-10-04 | 2020-09-02 | 18 |
| 22 | 2.1.1 | Formulation definition |  | 112d | 2018-10-04 | 2019-03-14 | 2 |
| 23 | 2.1.2 | Equipment sourcing |  | 56d | 2018-10-04 | 2018-12-20 | 22SS |
| 24 | 2.1.3 | Purchasing |  | 63d | 2018-10-04 | 2019-01-04 |  |
| 25 | 2.1.4 | Prototyping of equipment |  | 25d | 2019-01-07 | 2019-02-08 | 24 |
| 26 | 2.1.5 | Qualification protocols |  | 88d | 2018-10-04 | 2019-02-08 | 24SS |
| 27 | 2.1.6 | Qualification reports |  | 25d | 2019-02-11 | 2019-03-15 | 25FF, 26 |
| 28 | 2.1.7 | Development trials |  | 234d | 2018-10-04 | 2019-09-03 |  |
| 29 | 2.1.8 | Development summary report |  | 46d | 2019-07-01 | 2019-09-03 | 28FF |
| 30 | 2.1.9 | Verification plan and Protocols |  | 78d | 2019-09-04 | 2019-12-20 | 29 |
| 31 | 2.1.10 | Verification Summary report |  | 34d | 2020-01-06 | 2020-02-20 | 30, 38FF |
| 32 | 2.1.11 | Preliminary stability studies +25°C |  | 257d | 2019-09-04 | 2020-09-02 | 28, 30SS |
| 33 | 2.1.12 | Preliminary stability studies +40°C |  | 63d | 2019-09-04 | 2019-11-29 | 28, 30SS |

| ID | WBS | Task | Type | Duration | Start | Finish | Predecessors |
| --- | --- | --- | --- | --- | --- | --- | --- |
| 34 | 2.2 | **Analytical workpackage** |  | 332d | 2018-11-01 | 2020-02-20 |  |
| 35 | 2.2.1 | Analytical sourcing |  | 29d | 2018-11-01 | 2018-12-11 | 7 |
| 36 | 2.2.2 | Quality agreement |  | 22d | 2018-12-12 | 2019-01-16 | 35 |
| 37 | 2.2.3 | Analytical development |  | 139d | 2019-04-03 | 2019-10-15 | 28FF+30d, 36 |
| 38 | 2.2.4 | Analytical validation |  | 88d | 2019-10-16 | 2020-02-20 | 37 |
| 39 | 2.3 | **Engineering workpackage** |  | 243d | 2018-12-19 | 2019-11-29 |  |
| 40 | 2.3.1 | Filling process development |  | 90d | 2019-03-15 | 2019-07-18 | 22 |
| 41 | 2.3.2 | Filling process qualification protocol |  | 20d | 2019-06-21 | 2019-07-18 | 40FF |
| 42 | 2.3.3 | Qualification |  | 25d | 2019-07-19 | 2019-08-23 | 41 |
| 43 | 2.3.4 | Filling process qualification report |  | 40d | 2019-08-26 | 2019-10-18 | 40, 42 |
| 44 | 2.3.5 | Sterilization Development |  | 78d | 2018-12-19 | 2019-04-11 | 22FF+20d |
| 45 | 2.3.6 | Interim Device Master record |  | 63d | 2019-09-04 | 2019-11-29 | 29 |
| 46 | 2.4 | Technical Design Output - CH-FO-132 |  | 6d | 2020-02-21 | 2020-02-28 | 31 |
| 47 | 2.5 | Design Review 2 | milestone | 0d | 2020-03-02 | 2020-03-02 | 29, 31, 34, 45, 46 |
| 48 | 3 | **Process Validation Phase** |  | 360d | 2020-03-02 | 2021-07-20 |  |
| 49 | 3.1 | Master Validation Plan |  | 22d | 2020-03-02 | 2020-03-31 | 47 |
| 50 | 3.2 | **Process validation** |  | 360d | 2020-03-02 | 2021-07-20 |  |
| 51 | 3.2.1 | Process validation protocol |  | 50d | 2020-03-02 | 2020-05-08 | 47 |
| 52 | 3.2.2 | Batch1 : Process Validation |  | 11d | 2020-05-11 | 2020-05-25 | 43, 51 |
| 53 | 3.2.3 | Batch 2 : Process Validation |  | 12d | 2020-05-26 | 2020-06-10 | 52 |
| 54 | 3.2.4 | Batch 3 : Process Validation |  | 17d | 2020-06-11 | 2020-07-03 | 53 |
| 55 | 3.2.5 | Batches analysis |  | 45d | 2020-06-08 | 2020-08-07 | 38, 52SS, 54FF+25d |
| 56 | 3.2.6 | Process validation report |  | 44d | 2020-07-06 | 2020-09-03 | 54 |
| 57 | 3.2.7 | Interim stability study |  | 260d | 2020-07-06 | 2021-07-06 | 54 |
| 58 | 3.2.8 | Interim stability report |  | 10d | 2021-07-07 | 2021-07-20 | 57 |

| ID | WBS | Task | Type | Duration | Start | Finish | Predecessors |
| --- | --- | --- | --- | --- | --- | --- | --- |
| 59 | 3.3 | **Sterilization Validation** |  | 88d | 2020-04-01 | 2020-07-31 |  |
| 60 | 3.3.1 | Sterilization protocol |  | 20d | 2020-04-01 | 2020-04-28 | 44, 49 |
| 61 | 3.3.2 | Sterilization report |  | 20d | 2020-07-06 | 2020-07-31 | 54, 60 |
| 62 | 3.4 | **Visual control Validation** |  | 40d | 2020-06-08 | 2020-07-31 |  |
| 63 | 3.4.1 | Visual Control Validation protocol |  | 20d | 2020-06-08 | 2020-07-03 | 54FF |
| 64 | 3.4.2 | Visual Control validation report |  | 20d | 2020-07-06 | 2020-07-31 | 54 |
| 65 | 3.5 | Interim Master Validation Report |  | 20d | 2021-06-23 | 2021-07-20 | 58FF |
| 66 | 3.6 | Biocompatibility report |  | 60d | 2021-04-28 | 2021-07-20 |  |
| 67 | 3.7 | Gate review 3 | milestone | 0d | 2021-07-21 | 2021-07-21 | 65, 66FF |
| 68 | 4 | Final Design stage |  | 1d | 2018-06-01 | 2018-06-01 |  |
| 69 | 5 | **Clinical workpackage** |  | 1d | 2018-07-09 | 2018-07-09 |  |
| 70 | 5.1 | Clinical assesment |  | 1d | 2018-07-09 | 2018-07-09 |  |
| 71 | 5.2 | Clinical protocol |  | 1d | 2018-07-09 | 2018-07-09 |  |
| 72 | 5.3 | Clinical studies |  | 1d | 2018-07-09 | 2018-07-09 |  |
| 73 | 5.4 | Clinical report |  | 1d | 2018-07-09 | 2018-07-09 |  |
| 74 | 5.5 | Post market follow-up plan |  | 1d | 2018-07-09 | 2018-07-09 |  |
| 75 | 6 | **Sterilization shipping studies** |  | 1d | 2018-07-09 | 2018-07-09 |  |
| 76 | 6.1 | Protocol |  | 1d | 2018-07-09 | 2018-07-09 |  |
| 77 | 6.2 | Report |  | 1d | 2018-07-09 | 2018-07-09 |  |
| 78 | 7 | **Final Shipping studies** |  | 1d | 2018-07-09 | 2018-07-09 |  |
| 79 | 7.1 | Protocol |  | 1d | 2018-07-09 | 2018-07-09 |  |
| 80 | 7.2 | Report |  | 1d | 2018-07-09 | 2018-07-09 |  |
