# Chantiers Goutt'Alu Concept

Schedule from GanttProject, 2018-02-27 to 2018-10-31.
Goutt'Alu Concept
Chantiers Goutt'Alu Concept

## Calendars

- Project calendar: Mon-Fri working; Sat-Sun off. Exceptions (off unless hours are given): 2018-03-09 (Vacances sur 09/03/18 00:00), 2018-03-23 (Vacances sur 23/03/18 00:00), 2018-04-20 (Vacances sur 20/04/18 00:00), 2018-04-27 (Vacances sur 27/04/18 00:00), 2018-04-30 (Vacances sur 30/04/18 00:00), 2018-05-01 (Vacances sur 01/05/18 00:00), 2018-05-21 (Vacances sur 21/05/18 00:00), 2018-06-01, 2018-06-08 (Vacances sur 08/06/18 00:00), 2018-06-22 (Vacances sur 22/06/18 00:00), 2018-07-13 (Vacances sur 13/07/18 00:00), 2018-07-20 (Vacances sur 20/07/18 00:00), 2018-07-27 (Vacances sur 27/07/18 00:00), 2018-08-03 (Vacances sur 03/08/18 00:00), 2018-08-06 (Vacances sur 06/08/18 00:00), 2018-08-07 (Vacances sur 07/08/18 00:00), 2018-08-08 (Vacances sur 08/08/18 00:00), 2018-08-09 (Vacances sur 09/08/18 00:00), 2018-08-10 (Vacances sur 10/08/18 00:00), 2018-08-13 (Vacances sur 13/08/18 00:00), 2018-08-14 (Vacances sur 14/08/18 00:00), 2018-08-15 (Vacances sur 15/08/18 00:00), 2018-08-16 (Vacances sur 16/08/18 00:00), 2018-08-17 (Vacances sur 17/08/18 00:00), 2018-08-20 (Vacances sur 20/08/18 00:00), 2018-08-21 (Vacances sur 21/08/18 00:00), 2018-08-22 (Vacances sur 22/08/18 00:00), 2018-08-23 (Vacances sur 23/08/18 00:00), 2018-08-24 (Vacances sur 24/08/18 00:00), 2018-08-31 (Vacances sur 31/08/18 00:00), 2018-09-07 (Vacances sur 07/09/18 00:00).

## Resources

| Resource |
| --- |
| Alexis |
| CORNICHE |
| Fabien |
| LINEA |
| Loris |
| NACELLE 4X4 |
| NACELLE Camion |
| Nicolas |
| Romain |

## Schedule

| ID | WBS | Task | Type | Duration | Start | Finish | Complete | Resources |
| --- | --- | --- | --- | --- | --- | --- | --- | --- |
| 1 | 1 | selection artisanale genay |  | 1d | 2018-02-27 | 2018-02-27 | 100% |  |
| 2 | 2 | HENNEQUIN - fontaine / saone - GOUTT (2000) |  | 1d | 2018-02-27 | 2018-02-27 |  | CORNICHE |
| 3 | 3 | GOUY - solaize - bavette (300) |  | 1d | 2018-02-28 | 2018-02-28 | 37% |  |
| 4 | 4 | MAGANE - decines - 15 boites à eau + descentes |  | 1d | 2018-03-05 | 2018-03-05 |  |  |
| 5 | 5 | ALLOIN Laroche - Eclose - desct (500) |  | 1d | 2018-03-15 | 2018-03-15 |  | LINEA |
| 6 | 6 | VELGUE : cessieu : collecteur d'eau |  | 1d | 2018-03-15 | 2018-03-15 |  |  |
| 7 | 7 | TEKNITOIT Bennamour Goutt |  | 1d | 2018-03-19 | 2018-03-19 |  |  |
| 8 | 8 | AMARO - craponne - Desc bavette (1/2J) |  | 1d | 2018-03-19 | 2018-03-19 |  |  |
| 9 | 9 | GOUY - solaize - goutt spé + abergement (1300) |  | 1d | 2018-03-20 | 2018-03-20 |  | CORNICHE; Fabien; Nicolas |
| 10 | 10 | TEKNITOIT Pascal BD |  | 1d | 2018-03-21 | 2018-03-21 |  |  |
| 11 | 11 | St etienne |  | 1d | 2018-03-22 | 2018-03-22 |  |  |
| 12 | 12 | LOPEZ - Brignais - BD (2200) |  | 1d | 2018-03-19 | 2018-03-19 | 100% |  |
| 13 | 13 | ALLOIN - D'agostini |  | 2d | 2018-03-20 | 2018-03-21 |  |  |
| 14 | 14 | ALLOIN - Pechoux |  | 1d | 2018-03-21 | 2018-03-21 |  |  |
| 15 | 15 | DELMOTTE - meyzieu - ISO - tuile hotte + collecteur eau |  | 1d | 2018-03-22 | 2018-03-22 | 100% |  |
| 16 | 16 | GANDIT - genay - BD SF Gout (6000) |  | 3d | 2018-03-26 | 2018-03-28 |  | CORNICHE; Fabien; Nicolas |
| 17 | 17 | RAYMOND - genas - demoussant( 220 m2) |  | 1d | 2018-03-26 | 2018-03-26 |  | Romain |
| 18 | 18 | TEKNITOIT clermond |  | 2d | 2018-03-28 | 2018-03-29 |  |  |
| 19 | 19 | RAYMOND - genas SF BD GOUTT (7000) |  | 3d | 2018-03-27 | 2018-03-29 |  | CORNICHE; Loris; Romain |
| 20 | 20 | Alloin-tillet dagneux SF BD GOUTT |  | 1d | 2018-04-03 | 2018-04-03 |  |  |
| 21 | 21 | saint etienne renovation |  | 1d | 2018-04-04 | 2018-04-04 |  |  |
| 22 | 22 | Alloin Fraisses + descente zinc |  | 1d | 2018-04-06 | 2018-04-06 |  |  |
| 23 | 23 | CANNATA - mions - hydro (185m² 6h) |  | 1d | 2018-04-06 | 2018-04-06 |  | Fabien; Loris |
| 24 | 24 | Selection (martin) - caluire - |  | 1d | 2018-04-03 | 2018-04-03 |  |  |
| 25 | 25 | Alloin - Chedin - bandeau + main courante |  | 1d | 2018-04-03 | 2018-04-03 |  |  |
| 26 | 26 | CANNATA - mions - TOIT hydro (185m² 11h) |  | 1d | 2018-04-04 | 2018-04-04 |  |  |
| 27 | 27 | RAYMOND - genas - toit Hydro colore( 220 m2) |  | 1d | 2018-04-05 | 2018-04-05 |  |  |
| 28 | 28 | MOURET - decines - incolore (200m² 2h) |  | 1d | 2018-04-06 | 2018-04-06 |  |  |
| 29 | 29 | DUHEM - Lyon 9 - incolore (160m² 2h) |  | 1d | 2018-04-06 | 2018-04-06 | 54% |  |
| 30 | 30 | GIROUD-ARGOUD - Genas - TOIT demouss (280m²) |  | 1d | 2018-04-06 | 2018-04-06 | 54% |  |
| 31 | 31 | CANNATA - mions - SF BD GOUT (4200) |  | 2d | 2018-04-09 | 2018-04-10 | 47% | CORNICHE; Fabien; Loris |
| 32 | 32 | Copie_VACANCES NICO |  | 4d | 2018-04-09 | 2018-04-12 |  |  |
| 33 | 33 | CHATAIN - roche - Solarspot (1) |  | 1d | 2018-04-10 | 2018-04-10 | 33% | Fabien; Romain |
| 34 | 34 | CHATAIN - roche - SF BD GOUT (6000) |  | 3d | 2018-04-10 | 2018-04-12 | 36% | CORNICHE; Fabien; Loris; Romain |
| 35 | 35 | DEGUARRA - tour de salvagny - SF BD GOUTT (12000) |  | 4d | 2018-04-16 | 2018-04-19 |  | Romain |
| 36 | 36 | JARGOT - genas - toit demoussant (270m2) |  | 1d | 2018-04-17 | 2018-04-17 |  | Romain |
| 37 | 37 | SCI - oytier |  | 1d | 2018-04-19 | 2018-04-19 |  |  |
| 38 | 38 | JARGOT - genas - |  | 2d | 2018-04-23 | 2018-04-24 |  | Fabien; Nicolas |
| 39 | 39 | O'NEALL - genas - BD (400) |  | 1d | 2018-04-24 | 2018-04-24 |  |  |
| 40 | 40 | technitoit clermond |  | 2d | 2018-04-25 | 2018-04-26 |  |  |
| 41 | 41 | PRO NICO |  | 4d | 2018-04-23 | 2018-04-26 |  |  |
| 42 | 42 | JEANSELME - satonay - SF BD (4900) |  | 2d | 2018-05-02 | 2018-05-03 |  | Nicolas |
| 43 | 43 | inobat - montrottier - GOUTT desc |  | 1d | 2018-05-04 | 2018-05-04 |  |  |
| 44 | 44 | oytier - GOUTT |  | 1d | 2018-05-04 | 2018-05-04 |  |  |
| 45 | 45 | grenoble - GOUTT |  | 1d | 2018-05-04 | 2018-05-04 |  |  |
| 46 | 46 | CRESPO - jonage - toit (150m2 - 13h) |  | 2d | 2018-05-03 | 2018-05-04 |  | Romain |
| 47 | 47 | GIROUD-ARGOUD - Genas - BD (4000) |  | 2d | 2018-05-02 | 2018-05-03 |  | Romain |
| 48 | 48 | RIGAL - genas - GOUTT BD (2500) |  | 1d | 2018-05-29 | 2018-05-29 |  |  |
| 49 | 49 | MAGANE - decines - 3 boites à eau + descentes |  | 1d | 2018-05-18 | 2018-05-18 |  |  |
| 50 | 50 | GRECO - st priest - couvertine (5500) |  | 3d | 2018-05-28 | 2018-05-30 |  |  |
| 51 | 51 | salon des artisans genas | milestone | 0d | 2018-05-07 | 2018-05-07 |  | Alexis; Fabien; Loris; Nicolas |
| 52 | 52 | Société fermé |  | 5d | 2018-05-07 | 2018-05-11 |  |  |
| 53 | 53 | livraison isolation | milestone | 0d | 2018-05-14 | 2018-05-14 |  |  |
| 54 | 54 | DUHEM - lyon 9 - SF BD gout (4500) |  | 3d | 2018-05-14 | 2018-05-16 |  | LINEA |
| 55 | 55 | GOLONKA - st laurent - VELUX (1500) |  | 1d | 2018-05-17 | 2018-05-17 |  |  |
| 56 | 56 | CAMPANALE - genas - TOIT coloré (192m² 7h) |  | 1d | 2018-05-18 | 2018-05-18 |  |  |
| 57 | 57 | DEL MORAL - villefontaine - BD GOUTT (3000) |  | 2d | 2018-05-14 | 2018-05-15 |  |  |
| 58 | 58 | ALLOIN GEUGNEAU - nievroz - BD SF GOUTT (6000) |  | 3d | 2018-05-16 | 2018-05-18 |  | CORNICHE |
| 59 | 59 | ROUSSAT - montanay - BD (900) |  | 1d | 2018-05-22 | 2018-05-22 |  |  |
| 60 | 60 | JORRY - chassieu - BD SF (4200) |  | 3d | 2018-05-22 | 2018-05-24 |  |  |
| 61 | 61 | MANZETTI - vernaison - SOLARSPOT 530 (3800) |  | 1d | 2018-05-25 | 2018-05-25 |  | Alexis; NACELLE Camion; Nicolas; Romain |
| 62 | 62 | JARGOT - genas - hydro (270m2) |  | 1d | 2018-05-25 | 2018-05-25 |  | Romain |
| 63 | 63 | JARGOT - genas - descente |  | 1d | 2018-05-25 | 2018-05-25 |  |  |
| 64 | 64 | CROZET - pusignan - toit color (220m²) |  | 2d | 2018-05-22 | 2018-05-23 |  |  |
| 65 | 65 | CROZET - pusignan - SF BD GOUT pannes (5200) |  | 3d | 2018-05-23 | 2018-05-25 |  |  |
| 66 | 66 | MACHABERT - genas - SF BD GOUT pannes (6900) |  | 3d | 2018-05-28 | 2018-05-30 |  | CORNICHE |
| 67 | 67 | DURIEZ - genas - ISO ( 29 sacs) |  | 1d | 2018-05-31 | 2018-05-31 |  |  |
| 68 | 68 | LODI - st priest - ISO ( 22 sacs) |  | 1d | 2018-05-31 | 2018-05-31 |  |  |
| 69 | 69 | ROCHAS - st priest - ISO (15 sacs) |  | 1d | 2018-05-31 | 2018-05-31 |  |  |
| 70 | 70 | PRO NICO |  | 4d | 2018-05-28 | 2018-05-31 |  |  |

Notes:
- 12: semaine 14 annoncée
- 16: prévu 26 mars
- 17: absent du 12 au 24 mars
- 19: absent du 12 au 24 mars
- 27: absent du 12 au 24 mars
- 29: après le 3 avril / tuile beton a remplacer par une terre cuite
- 42: prévu semaine 16 les 18 19
- 46: a faire avant mai
- 48: ASAP
- 49: après le 23
- 54: ne pas décaler !
- 55: prévu le 17 mai . Travaux de peinture la semaine suivante. Ne pas déplacer
- 56: ou début mars si trop risqué. Mec super maniaque
- 69: S25 ou 26

| ID | WBS | Task | Duration | Start | Finish | Resources |
| --- | --- | --- | --- | --- | --- | --- |
| 71 | 71 | copie Lavallard XIONG - VONNAS - GOUTT (2500) | 1d | 2018-05-28 | 2018-05-28 |  |
| 72 | 72 | SEGUARD - isle d'abeau - ISO ( 25 sacs) | 1d | 2018-06-04 | 2018-06-04 |  |
| 73 | 73 | Lavallard XIONG - VONNAS - ISO ( 48 sacs) | 1d | 2018-06-04 | 2018-06-04 |  |
| 74 | 74 | GADOU - meyzieu - iso (29 sacs) | 1d | 2018-06-05 | 2018-06-05 |  |
| 75 | 75 | PRO NICO | 2d | 2018-06-06 | 2018-06-07 |  |
| 76 | 76 | BASTET - genas - SF BD pannes (3300) | 2d | 2018-06-04 | 2018-06-05 |  |
| 77 | 77 | FUSTER - communay - SF BD GOUTT (4100) | 2d | 2018-06-06 | 2018-06-07 |  |
| 78 | 78 | DURIEZ - genas - SF BD (2000) | 1d | 2018-06-11 | 2018-06-11 |  |
| 79 | 79 | SAINT CHELY - st priest - BD GOUTT (3000) | 2d | 2018-06-12 | 2018-06-13 |  |
| 80 | 80 | ROCHAS - st priest - TOIT (196m²) | 2d | 2018-06-11 | 2018-06-12 |  |
| 81 | 81 | DIDONNA - genas - toit hydro (170m²) | 1d | 2018-06-13 | 2018-06-13 |  |
| 82 | 82 | GADOU - meyzieu - toit hydro (170m²) | 1d | 2018-06-14 | 2018-06-14 |  |
| 83 | 83 | ROCHAS - st priest - BD SF GOUTT (5600) | 3d | 2018-06-18 | 2018-06-20 |  |
| 84 | 84 | BOIRIVENT - craponne - BD SF (2400) | 2d | 2018-06-20 | 2018-06-21 |  |
| 85 | 85 | HENNEQUIN - fontaine / saone - DESCENTES (500) | 1d | 2018-06-18 | 2018-06-18 |  |
| 86 | 86 | PEDRON - heyrieux - SF BD GOUTT (7000) | 4d | 2018-06-18 | 2018-06-21 |  |
| 87 | 87 | Lavallard XIONG - VONNAS - GOUTT (2500) | 1d | 2018-06-25 | 2018-06-25 |  |
| 88 | 88 | SCHNEEWEIS - jonage - GOUTT BD (2000) | 1d | 2018-06-25 | 2018-06-25 |  |
| 89 | 89 | AUTIN - grigny - BD | 1d | 2018-06-26 | 2018-06-26 |  |
| 90 | 90 | GADOU - meyzieu - SF BD (4400) | 2d | 2018-06-25 | 2018-06-26 |  |
| 91 | 91 | Lydie DENIS RAMOUSSET - genas - BD GOUTT (2700) | 2d | 2018-07-02 | 2018-07-03 | LINEA |
| 92 | 92 | COLLE - genas - BD GOUTT (2500) | 2d | 2018-07-04 | 2018-07-05 | LINEA |
| 93 | 93 | **Lot CHASSIEU Nico - BD ( 7 maisons )** | 4d | 2018-07-02 | 2018-07-05 |  |
| 94 | 93.1 | MAYER - chassieu - BD (1700) | 1d | 2018-07-02 | 2018-07-02 |  |
| 95 | 93.2 | COCHAT - chassieu - BD (1700) | 1d | 2018-07-03 | 2018-07-03 |  |
| 96 | 93.3 | TRELCAT - chassieu - BD (1700) | 1d | 2018-07-04 | 2018-07-04 |  |
| 97 | 93.4 | TRELCAT - chassieu - BD (1700) | 1d | 2018-07-05 | 2018-07-05 |  |
| 98 | 93.5 | BOITEUX - chassieu - BD (1700) | 1d | 2018-07-05 | 2018-07-05 |  |
| 99 | 94 | PRO NICO | 4d | 2018-07-09 | 2018-07-12 |  |
| 100 | 95 | DIDONNA - GENAS - SF BD GOUTT (6000) | 3d | 2018-07-09 | 2018-07-11 |  |
| 101 | 96 | copie DIDONNA - GENAS - SF BD GOUTT (6000) | 3d | 2018-08-27 | 2018-08-29 |  |
| 102 | 97 | SAINTE BARBE - meyzieu - SF BD GOUTT (4500) | 2d | 2018-07-16 | 2018-07-17 |  |
| 103 | 98 | PRO NICO | 4d | 2018-07-30 | 2018-08-02 |  |
| 104 | 99 | R les glycines - st quentin f - BD (1000) | 2d | 2018-09-10 | 2018-09-11 |  |
| 105 | 100 | LEGUE - genas - SF BD (4600) | 2d | 2018-09-24 | 2018-09-25 |  |
| 106 | 101 | DENIAU - 71 - SF BD (5200) | 3d | 2018-10-29 | 2018-10-31 |  |

Notes:
- 80: S25 ou 26
- 83: S25 ou 26
- 84: S25 ou 26
- 88: ne pas décaler après car le client refait sa terrasse
- 89: option - reponse en avril / pas dispo en juillet
